# GreenHouse Gantt Chart

Schedule from MS Project, 2017-03-02 to 2017-06-18, status date 2017-06-01, costs in €, A marks actual dates.

## Calendars

- Standard: Mon-Fri 08:00-12:00, 13:00-17:00; Sat-Sun off.

## Resources

| Resource | Rate |
| --- | --- |
| Alisson | 10 |
| Christophe | 10 |
| Cristina | 10 |
| Antonio | 10 |
| Mathias | 10 |
| wood frame winter cover | 1 |
| wood frame top structure | 3.39 |
| wood frame bottom structure | 4.79 |
| panel | 9.98 |
| foam | 2.89 |
| plastic foil inside | 3.49 |
| transparent foil wonter cover | 4.99 |
| aluminium frame | 2.99 |
| steel tubes support | 7.98 |
| screws 4*12 | 1.99 |
| screws 4*40 | 1.99 |
| shaman | 8.58 |
| glue | 2.39 |
| watring system | 1.99 |
| temperatur sensor | 6.7 |
| rain sensor | 6.13 |
| micro switch | 2.22 |
| push button | 5.8 |
| switch | 0.9 |
| wire | 3.49 |
| control system | 22.99 |
| geared DC motor | 14.45 |
| batteries | 3 |
| battery holder | 2.9 |
| motor controller | 2.46 |
| clip for led | 0.32 |
| green led | 0.32 |
| red led | 0.32 |
| resistors | 0.9 |
| float switch | 4.99 |

## Schedule

| ID | WBS | Task | Type | Duration | Start | Finish | Predecessors | Complete | Remaining | Baseline start | Baseline finish | Baseline duration | Deadline | Resources | Work | Actual work | Cost | Baseline cost | Actual cost |
| --- | --- | --- | --- | --- | --- | --- | --- | --- | --- | --- | --- | --- | --- | --- | --- | --- | --- | --- | --- |
| 1 | 1 | **Plan** |  | 3d | 2017-03-02 A | 2017-03-06 A |  | 100% |  | 2017-03-02 | 2017-03-06 | 3d |  |  | 48h | 48h | 480 | 1,080 | 480 |
| 2 | 1.1 | allocation tasks | manual | 2d | 2017-03-02 A | 2017-03-03 A |  | 100% |  | 2017-03-02 | 2017-03-03 | 2d |  | Alisson [50%]; Antonio [50%]; Christophe [50%]; Cristina [50%]; Mathias [50%] | 40h | 40h | 400 | 400 | 400 |
| 3 | 1.2 | gantt | manual | 1d | 2017-03-06 A | 2017-03-06 A | 2 | 100% |  | 2017-03-06 | 2017-03-06 | 1d |  | Alisson [50%]; Christophe [50%] | 8h | 8h | 80 | 80 | 80 |
| 4 | 2 | **Research and development** |  | 41d | 2017-03-07 A | 2017-05-02 |  | 92% | 3.26d | 2017-03-07 | 2017-05-02 | 41d |  | Alisson [10%]; Antonio [10%]; Christophe [10%]; Cristina [10%]; Mathias [10%] | 859.28h | 430.08h | 8,592.8 | 10,227.2 | 4,300.8 |
| 5 | 2.1 | **Marketing** |  | 1d | 2017-03-07 A | 2017-03-07 A |  | 100% |  | 2017-03-07 | 2017-03-07 | 1d |  | Cristina [10%]; Alisson [10%]; Antonio [10%] | 8.8h | 8.8h | 88 | 72 | 88 |
| 6 | 2.1.1 | Target | manual | 1d | 2017-03-07 A | 2017-03-07 A | 2 | 100% |  | 2017-03-07 | 2017-03-07 | 1d |  | Cristina [10%] | 0.8h | 0.8h | 8 | 16 | 8 |
| 7 | 2.1.2 | Research and choice of the plant | manual | 1d | 2017-03-07 A | 2017-03-07 A | 2 | 100% |  |  |  |  |  | Cristina [10%]; Mathias [10%]; Alisson [10%] | 2.4h | 2.4h | 24 |  | 24 |
| 8 | 2.1.3 | Analysis of competitors | manual | 1d | 2017-03-07 A | 2017-03-07 A | 2 | 100% |  |  |  |  |  | Cristina [20%]; Alisson [20%] | 3.2h | 3.2h | 32 |  | 32 |
| 9 | 2.2 | **Sustainability** |  | 1d | 2017-03-08 A | 2017-03-08 A |  | 100% |  | 2017-03-08 | 2017-03-08 | 1d |  | Christophe [20%]; Cristina | 3.2h | 3.2h | 32 | 32 | 32 |
| 10 | 2.2.1 | Research and choice of resources | manual | 1d | 2017-03-08 A | 2017-03-08 A | 6 | 100% |  |  |  |  |  | Christophe [20%]; Cristina [20%] | 3.2h | 3.2h | 32 |  | 32 |
| 11 | 2.3 | **Electronic and Mechanic** |  | 3d | 2017-03-09 A | 2017-03-13 A |  | 100% |  | 2017-03-09 | 2017-03-13 | 3d |  | Christophe [10%]; Antonio [10%]; Mathias [10%] | 19.2h | 19.2h | 192 | 160 | 192 |
| 12 | 2.3.1 | research on components | manual | 1d | 2017-03-09 A | 2017-03-09 A |  | 100% |  | 2017-03-09 | 2017-03-09 | 1d |  | Christophe [10%]; Antonio [10%]; Mathias [10%] | 2.4h | 2.4h | 24 | 24 | 24 |
| 13 | 2.3.2 | Controlling system code | manual | 2d | 2017-03-10 A | 2017-03-13 A | 12 | 100% |  | 2017-03-10 | 2017-03-13 | 2d |  | Christophe [10%] | 1.6h | 1.6h | 16 | 16 | 16 |
| 14 | 2.3.3 | Blackbox diagram | manual | 2d | 2017-03-10 A | 2017-03-13 A | 12 | 100% |  |  |  |  |  | Mathias [20%] | 3.2h | 3.2h | 32 |  | 32 |
| 15 | 2.3.4 | structural draft | manual | 2d | 2017-03-10 A | 2017-03-13 A | 12 | 100% |  |  |  |  |  | Cristina [20%] | 3.2h | 3.2h | 32 |  | 32 |
| 16 | 2.3.5 | Black box diagrams and srtuctural draft | milestone, manual | 0d | 2017-03-13 A | 2017-03-13 A | 14, 15 | 100% |  | 2017-03-13 | 2017-03-13 | 0d | 2017-03-13 |  |  |  |  |  |  |
| 17 | 2.3.6 | electronic schematic | manual | 1d | 2017-03-10 A | 2017-03-10 A | 12 | 100% |  |  |  |  |  | Mathias [20%] | 1.6h | 1.6h | 16 |  | 16 |
| 18 | 2.4 | **Design** |  | 13d | 2017-03-09 A | 2017-03-27 A |  | 100% |  | 2017-03-09 | 2017-03-28 | 14d |  | Cristina [10%]; Antonio [10%]; Alisson [10%] | 54.4h | 54.4h | 544 | 520 | 544 |
| 19 | 2.4.1 | drawings | manual | 5d | 2017-03-09 A | 2017-03-15 A |  | 100% |  | 2017-03-09 | 2017-03-15 | 5d |  | Cristina [20%]; Antonio [10%] | 12h | 12h | 120 | 120 | 120 |
| 20 | 2.4.2 | solidworks structural schematic | manual | 6d | 2017-03-16 A | 2017-03-23 A | 19 | 100% |  | 2017-03-16 | 2017-03-23 | 6d |  | Antonio [10%] | 4.8h | 4.8h | 48 | 48 | 48 |
| 21 | 2.4.3 | cardboard scale model | manual | 2d | 2017-03-24 A | 2017-03-27 A | 20 | 100% |  |  |  |  |  | Alisson [10%]; Cristina [10%]; Antonio [10%]; Mathias [10%] | 6.4h | 6.4h | 64 |  | 64 |
| 22 | 2.4.4 | structural schematic and cardboard scale model | milestone, manual | 0d | 2017-03-27 A | 2017-03-27 A |  | 100% |  | 2017-03-27 | 2017-03-27 | 0d | 2017-03-27 |  |  |  |  |  |  |
| 23 | 2.5 | **Ethical and deontological** |  | 7d | 2017-03-10 A | 2017-03-20 A |  | 100% |  | 2017-03-10 | 2017-03-20 | 7d |  | Christophe [10%] | 11.2h | 11.2h | 112 | 112 | 112 |
| 24 | 2.5.1 | legal research | manual | 7d | 2017-03-10 A | 2017-03-20 A | 12 | 100% |  | 2017-03-10 | 2017-03-20 | 7d |  | Christophe [10%] | 5.6h | 5.6h | 56 | 56 | 56 |

| ID | WBS | Task | Type | Duration | Start | Finish | Predecessors | Complete | Remaining | Baseline start | Baseline finish | Baseline duration | Resources | Work | Actual work | Cost | Baseline cost | Actual cost |
| --- | --- | --- | --- | --- | --- | --- | --- | --- | --- | --- | --- | --- | --- | --- | --- | --- | --- | --- |
| 25 | 2.6 | **Materials** |  | 25d | 2017-03-21 A | 2017-04-24 |  | 99% | 0d | 2017-03-21 | 2017-04-24 | 25d | Alisson [10%]; Antonio [10%]; Christophe [5%]; Cristina [10%]; Mathias [10%] | 154h | 84h | 1,540 | 1,632 | 840 |
| 26 | 2.6.1 | budget | manual | 9d | 2017-03-21 A | 2017-03-31 A | 24, 12 | 100% |  | 2017-03-21 | 2017-03-31 | 9d | Cristina [10%] | 7.2h | 7.2h | 72 | 72 | 72 |
| 27 | 2.6.2 | research on materials | manual | 9d | 2017-03-21 A | 2017-03-31 A | 24, 12 | 100% |  | 2017-03-21 | 2017-03-31 | 9d | Antonio [10%]; Mathias [10%] | 14.4h | 14.4h | 144 | 360 | 144 |
| 28 | 2.6.3 | list of materials | manual | 1d | 2017-04-03 A | 2017-04-03 A | 27 | 100% |  | 2017-04-03 | 2017-04-03 | 1d | Antonio [10%]; Cristina [10%]; Mathias [10%] | 2.4h | 2.4h | 24 | 40 | 24 |
| 29 | 2.6.4 | definitive list of materials | manual | 15d | 2017-04-04 A | 2017-04-24 A | 28 | 100% |  | 2017-04-04 | 2017-04-24 | 15d | Antonio [30%]; Cristina [10%]; Mathias [10%] | 60h | 60h | 600 | 360 | 600 |
| 30 | 2.7 | **Report and presentation** |  | 41d | 2017-03-07 A | 2017-05-02 |  | 89% | 4.35d | 2017-03-07 | 2017-05-02 | 41d | Alisson [5%]; Antonio [10%]; Christophe [5%]; Cristina [10%]; Mathias [10%] | 444.48h | 249.28h | 4,444.8 | 6,059.2 | 2,492.8 |
| 31 | 2.7.1 | state of the art written part | manual | 24d | 2017-03-07 A | 2017-04-07 A | 2 | 100% |  | 2017-03-07 | 2017-04-07 | 24d | Antonio [10%] | 19.2h | 19.2h | 192 | 384 | 192 |
| 32 | 2.7.2 | project management written part | manual | 24d | 2017-03-07 A | 2017-04-07 A | 2 | 100% |  | 2017-03-07 | 2017-04-07 | 24d | Alisson [5%] | 14.4h | 14.4h | 144 | 192 | 144 |
| 33 | 2.7.3 | marketing written part | manual | 23d | 2017-03-08 A | 2017-04-07 A | 6 | 100% |  | 2017-03-08 | 2017-04-07 | 23d | Alisson [10%]; Christophe [10%]; Cristina [10%] | 36.8h | 36.8h | 368 | 184 | 368 |
| 34 | 2.7.4 | eco efficienty measures for sustainability written part | manual | 22d | 2017-03-09 A | 2017-04-07 A |  | 100% |  | 2017-03-09 | 2017-04-07 | 22d | Mathias [20%] | 35.2h | 35.2h | 352 | 352 | 352 |
| 35 | 2.7.5 | Ethical and deontological concerns written part | manual | 14d | 2017-03-21 A | 2017-04-07 A | 24 | 100% |  | 2017-03-21 | 2017-04-07 | 14d | Christophe [20%] | 22.4h | 22.4h | 224 | 224 | 224 |
| 36 | 2.7.6 | Packaging written part | manual | 8d | 2017-03-29 A | 2017-04-07 A | 22 | 100% |  |  |  |  | Alisson [10%] | 16h | 16h | 160 |  | 160 |
| 37 | 2.7.7 | Project development written part | manual | 19d | 2017-03-14 A | 2017-04-07 | 13 | 50% | 9.5d | 2017-03-14 | 2017-04-07 | 19d | Christophe [20%]; Antonio [10%]; Alisson [10%]; Cristina [10%]; Mathias [10%] | 68.4h | 22.8h | 684 | 456 | 228 |
| 38 | 2.7.8 | Other written parts | manual | 23d | 2017-03-08 A | 2017-04-07 | 6 | 50% | 11.5d |  |  |  | Christophe [20%] | 36.8h | 18.4h | 368 |  | 184 |
| 39 | 2.7.9 | Interim presentation | manual | 24d | 2017-03-07 A | 2017-04-07 A | 2 | 100% |  | 2017-03-07 | 2017-04-07 | 24d | Cristina [10%] | 19.2h | 19.2h | 192 | 192 | 192 |
| 40 | 2.7.10 | Interim report refined | manual | 17d | 2017-04-10 A | 2017-05-02 A | 31, 32, 33, 34, 35, 37 | 100% |  | 2017-04-10 | 2017-05-02 | 17d | Christophe [33%] | 44.88h | 44.88h | 448.8 | 2,067.2 | 448.8 |
| 41 | 3 | **Production** |  | 30d | 2017-04-25 A | 2017-06-05 |  | 74% | 7.87d | 2017-05-03 | 2017-06-05 | 24d | Alisson [50%]; Antonio [20%]; Christophe [20%]; Cristina [20%]; Mathias [50%] | 591.2h | 82h | 6,048.33 | 4,864 | 928.11 |
| 42 | 3.1 | **Electronical** |  | 11d | 2017-05-03 A | 2017-05-17 |  | 99% | 0d | 2017-05-03 | 2017-05-17 | 11d | Christophe [20%] | 52.8h | 35.2h | 590.97 | 352 | 414.97 |
| 43 | 3.1.1 | engineering electronics | manual | 6d | 2017-05-03 A | 2017-05-10 A | 40 | 100% |  | 2017-05-03 | 2017-05-10 | 6d | Christophe [20%]; temperatur sensor; rain sensor; Mathias [20%]; batteries; battery holder; clip for led; control system; float switch; green led; micro switch; push button; wire; red led; resistors; switch; watring system | 19.2h | 19.2h | 254.97 | 96 | 254.97 |
| 44 | 3.1.2 | testing electronics | manual | 5d | 2017-05-11 A | 2017-05-17 A | 43 | 100% |  | 2017-05-11 | 2017-05-17 | 5d | Christophe [20%]; Mathias [20%] | 16h | 16h | 160 | 80 | 160 |
| 45 | 3.2 | **Mechanical** |  | 11d | 2017-05-03 A | 2017-05-17 |  | 99% | 0d | 2017-05-03 | 2017-05-17 | 11d | Antonio [10%] | 21.6h | 12.8h | 232.91 | 216 | 144.91 |
| 46 | 3.2.1 | engineering mechanics | manual | 6d | 2017-05-03 A | 2017-05-10 A | 40 | 100% |  | 2017-05-03 | 2017-05-10 | 6d | Antonio [10%]; motor controller; geared DC motor | 4.8h | 4.8h | 64.91 | 48 | 64.91 |
| 47 | 3.2.2 | testing machanics | manual | 5d | 2017-05-11 A | 2017-05-17 A | 46 | 100% |  | 2017-05-11 | 2017-05-17 | 5d | Antonio [20%] | 8h | 8h | 80 | 80 | 80 |
| 48 | 3.3 | **Structure and Plants** |  | 11d | 2017-05-03 A | 2017-05-17 |  | 82% | 1.94d | 2017-05-03 | 2017-05-17 | 11d | Alisson [10%]; Cristina [10%]; Mathias [10%]; Antonio [10%] | 70.4h | 30.4h | 760.45 | 704 | 332.23 |
| 49 | 3.3.1 | gardening | manual | 6d | 2017-05-03 A | 2017-05-10 A | 40 | 100% |  | 2017-05-03 | 2017-05-10 | 6d | Cristina [10%]; Alisson [10%] | 9.6h | 9.6h | 96 | 96 | 96 |
| 50 | 3.3.2 | build the structure | manual | 6d | 2017-05-03 A | 2017-05-10 | 40 | 50% | 3d | 2017-05-03 | 2017-05-10 | 6d | Mathias [10%]; Antonio [10%]; wood frame bottom structure; shaman; wood frame top structure; screws 4*40; panel; steel tubes support; wood frame winter cover; aluminium frame; foam; glue; plastic foil inside; screws 4*12; transparent foil wonter cover | 9.6h | 4.8h | 152.45 | 96 | 76.22 |
| 51 | 3.3.3 | testing structure | manual | 5d | 2017-05-11 A | 2017-05-17 A | 50 | 100% |  | 2017-05-11 | 2017-05-17 | 5d | Alisson [10%]; Antonio [10%]; Cristina [10%]; Mathias [10%] | 16h | 16h | 160 | 160 | 160 |

| ID | WBS | Task | Type | Duration | Start | Finish | Predecessors | Complete | Remaining | Baseline start | Baseline finish | Baseline duration | Deadline | Resources | Work | Actual work | Cost | Baseline cost | Actual cost |
| --- | --- | --- | --- | --- | --- | --- | --- | --- | --- | --- | --- | --- | --- | --- | --- | --- | --- | --- | --- |
| 52 | 3.4 | **Packaging** |  | 17d | 2017-04-25 A | 2017-05-17 | 29 | 99% | 0d |  |  |  |  | Alisson [5%] | 10.4h | 3.6h | 104 |  | 36 |
| 53 | 3.4.1 | blank | manual | 4d | 2017-04-25 A | 2017-04-28 A | 29 | 100% |  |  |  |  |  | Alisson [5%] | 1.6h | 1.6h | 16 |  | 16 |
| 54 | 3.4.2 | graphic design | manual | 5d | 2017-05-01 A | 2017-05-05 A | 53 | 100% |  |  |  |  |  | Alisson [5%] | 2h | 2h | 20 |  | 20 |
| 55 | 3.5 | Assembly | manual | 5d | 2017-05-18 | 2017-05-24 | 44, 47, 51 |  |  | 2017-05-18 | 2017-05-24 | 5d |  | Alisson [10%]; Antonio [10%]; Christophe [10%]; Cristina [10%]; Mathias [10%] | 20h |  | 200 | 200 |  |
| 56 | 3.6 | Testing and validation | manual | 8d | 2017-05-25 | 2017-06-05 | 55 |  |  | 2017-05-25 | 2017-06-05 | 8d |  | Alisson [10%]; Antonio [10%]; Christophe [10%]; Cristina [10%]; Mathias [10%] | 32h |  | 320 | 320 |  |
| 57 | 4 | Report | manual | 33d | 2017-05-03 A | 2017-06-16 | 40 | 50% | 16.5d | 2017-05-03 | 2017-06-16 | 33d |  | Alisson [10%]; Antonio [10%]; Christophe [10%]; Cristina [10%]; Mathias [10%] | 132h | 66h | 1,320 | 1,320 | 660 |
| 58 | 5 | Presentation | manual | 49d | 2017-04-10 A | 2017-06-15 | 39 | 50% | 24.5d | 2017-04-10 | 2017-06-16 | 50d |  | Cristina [10%] | 39.2h | 19.6h | 392 | 400 | 196 |
| 59 | 6 | Leaflet | manual | 9d | 2017-06-06 A | 2017-06-16 A | 56 | 100% |  | 2017-06-06 | 2017-06-16 | 9d |  | Alisson [10%] | 7.2h | 7.2h | 72 | 72 | 72 |
| 60 | 7 | Poster | manual | 10d | 2017-05-18 A | 2017-05-31 | 40 | 50% | 5d |  |  |  |  | Cristina [10%] | 8h | 4h | 80 |  | 40 |
| 61 | 8 | Video | manual | 9d | 2017-06-06 | 2017-06-16 | 56 |  |  | 2017-06-06 | 2017-06-16 | 9d |  | Christophe [10%] | 7.2h |  | 72 | 144 |  |
| 62 | 9 | Website | manual | 9d | 2017-06-06 A | 2017-06-16 A | 56 | 100% |  | 2017-06-06 | 2017-06-16 | 9d |  | Alisson [10%] | 7.2h | 7.2h | 72 | 360 | 72 |
| 63 | 10 | Wiki | manual | 74d | 2017-03-07 A | 2017-06-16 | 2 | 50% | 37d | 2017-03-07 | 2017-06-16 | 74d |  | Alisson [10%]; Christophe [10%] | 118.4h | 59.2h | 1,184 | 2,960 | 592 |
| 64 | 11 | Product | manual | 9d | 2017-06-06 A | 2017-06-16 | 56 | 50% | 4.5d | 2017-06-06 | 2017-06-16 | 9d |  | Alisson [10%]; Antonio [10%]; Christophe [10%]; Cristina [10%]; Mathias [10%] | 36h | 18h | 360 | 360 | 180 |
| 65 | 12 | CD | manual | 1d | 2017-06-16 | 2017-06-16 | 58 |  |  |  |  |  |  | Alisson [5%]; Antonio [5%]; Christophe [5%]; Cristina [5%]; Mathias [5%] | 2h |  | 20 |  |  |
| 66 | 13 | Instruction manual | manual | 10d | 2017-05-18 A | 2017-05-31 | 40 | 50% | 5d | 2017-06-06 | 2017-06-18 | 10d |  | Alisson [5%]; Antonio [5%]; Mathias [5%] | 18h | 12h | 180 | 400 | 120 |
| 67 | 14 | Milestone Delivery | milestone, manual | 0d | 2017-06-18 | 2017-06-18 | 57, 58, 59, 62, 61, 63, 64, 66 |  |  | 2017-06-18 | 2017-06-18 | 0d | 2017-06-18 |  |  |  |  |  |  |
